# LRAUVBuildScheduleRev.A

Schedule from MS Project, 2017-09-27 to 2018-07-05, A marks actual dates.
Hewlett-Packard Company

## Calendars

- Standard: Mon-Fri 08:00-12:00, 13:00-17:00; Sat-Sun off.

## Resources

| Resource |
| --- |
| Water Rat |
| Jim Scholfield |
| Mark Chaffey |
| Jose Rosal |
| Ken Heller |
| Denis Klimov |
| Ed Mellinger |
| Brett Hobson |
| Brian Kieft |
| Mike Parker |
| Machine Shop |
| Jon Erickson |
| Craig Okuda |
| Pleskunas Design LLC |
| Ben |
| Paul Coenen |

## Schedule

| ID | WBS | Task | Type | Duration | Start | Finish | Predecessors | Complete | Remaining | Total slack | Free slack | Constraint | Resources | Work | Actual work |
| --- | --- | --- | --- | --- | --- | --- | --- | --- | --- | --- | --- | --- | --- | --- | --- |
| 1 | 1 | **A-200467-17_PressHull_BUILD_5** |  | 146.5d | 2017-09-27 A | 2018-04-19 |  | 78% | 32.93d | 55.25d |  |  |  | 2786h | 2133.2h |
| 2 | 1.1 | Receive P-200626_AlumPressHull_EndDome_FWD_Rev.G |  | 1d | 2017-09-27 A | 2017-09-27 A |  | 100% |  |  |  |  |  |  |  |
| 3 | 1.2 | Receive fwd bulkhead connectors |  | 10d | 2017-09-27 A | 2017-10-10 A |  | 100% |  |  |  |  |  |  |  |
| 4 | 1.3 | FWD dome wiring |  | 5d | 2017-10-11 A | 2018-01-15 A | 3, 2 | 100% |  |  |  |  | Jose Rosal | 40h | 40h |
| 5 | 1.4 | Assemble A-200579-14_InternalChassis_V3 |  | 10d | 2017-11-15 A | 2018-03-07 | 4 | 25% | 7.5d | 35.5d | 11d |  | Jim Scholfield | 80h | 20h |
| 6 | 1.5 | Receive P-200466-08_EndDome_AFT_Rev.C |  | 1d | 2017-09-27 A | 2017-09-27 A |  | 100% |  |  |  | start no earlier than 2017-09-27 |  |  |  |
| 7 | 1.6 | Receive aft bulkhead connectors |  | 10d | 2017-09-27 A | 2017-10-10 A |  | 100% |  |  |  |  |  |  |  |
| 8 | 1.7 | AFT dome wiring |  | 5d | 2017-10-11 A | 2018-01-15 A | 7, 6 | 100% |  |  |  |  | Jose Rosal | 40h | 40h |
| 9 | 1.8 | **A-201330-12_VB-Sys_V2** |  | 75.25d | 2017-09-27 A | 2018-01-10 A |  | 100% |  |  |  |  |  | 40h | 40h |
| 10 | 1.8.1 | A-200620-08_VB-Resrvoir |  | 2.5d | 2017-09-27 A | 2018-01-10 A |  | 100% |  |  |  | start no earlier than 2017-09-27 | Jim Scholfield | 20h | 20h |
| 11 | 1.8.2 | A-200991-11_ValveAssem final assembly |  | 2.5d | 2017-09-27 A | 2017-10-03 A |  | 100% |  |  |  | start no earlier than 2017-09-27 | Jim Scholfield | 20h | 20h |
| 12 | 1.9 | **A-201541-13_SecBattAssem_V3.3** |  | 126.5d | 2017-09-27 A | 2018-03-22 |  | 68% | 40.56d | 2.5d |  | start no earlier than 2017-09-27 |  | 568h | 418h |
| 13 | 1.9.1 | Assemble half-pak battery modules |  | 5d | 2017-09-27 A | 2017-11-16 A |  | 100% |  |  |  | start no earlier than 2017-09-27 | Denis Klimov; Ken Heller | 80h | 80h |
| 14 | 1.9.2 | Test half-pak battery modules |  | 20d | 2017-11-17 A | 2018-03-01 | 13 | 80% | 4d | 28.25d | 0d | start no earlier than 2017-11-17 | Denis Klimov; Ken Heller | 320h | 256h |
| 15 | 1.9.3 | Degauss half-pak battery modules |  | 6d | 2018-01-16 A | 2018-03-08 | 14 | 25% | 4.5d | 28.25d | 0d | start no earlier than 2018-01-08 | Denis Klimov | 48h | 12h |
| 16 | 1.9.4 | Assemble complete battery module |  | 5d | 2018-03-08 A | 2018-03-15 | 15 | 75% | 1.25d | 24.5d | 0d | start no earlier than 2018-02-23 | Ken Heller | 40h | 30h |
| 17 | 1.9.5 | A-201907-17_FlagAssem_V2 |  | 5d | 2018-03-15 | 2018-03-22 | 16 |  |  | 24.5d | 0d | start no earlier than 2018-02-23 | Jim Scholfield | 40h |  |
| 18 | 1.9.6 | A-201567-14_Complete Drive Assembly_V4 |  | 5d | 2018-01-31 A | 2018-02-06 A | 16 | 100% |  |  |  | start no earlier than 2018-01-08 | Jim Scholfield | 40h | 40h |
| 19 | 1.10 | **A-201882-17_RF chassis_V2** |  | 49.25d | 2017-11-10 A | 2018-01-18 A |  | 100% |  |  |  | start no earlier than 2017-11-10 |  | 320h | 320h |
| 20 | 1.10.1 | Replace RF MUX PCB component |  | 30d | 2017-11-10 A | 2017-12-21 A |  | 100% |  |  |  | start no earlier than 2017-11-10 | Jose Rosal | 240h | 240h |
| 21 | 1.10.2 | 3 way mux assembly complete |  | 5d | 2017-12-22 A | 2018-01-11 A | 20 | 100% |  |  |  | start no earlier than 2017-12-22 | Jose Rosal | 40h | 40h |
| 22 | 1.10.3 | Test 3 way mux assembly |  | 5d | 2018-01-11 A | 2018-01-18 A | 21 | 100% |  |  |  | start no earlier than 2018-01-05 | Craig Okuda | 40h | 40h |
| 23 | 1.11 | **A-201904-17_LoadContAssem_V2** |  | 122d | 2017-09-27 A | 2018-03-15 |  | 74% | 31.49d | 79.75d |  |  |  | 860h | 638h |
| 24 | 1.11.1 | Receive and configure load control boards |  | 2.5d | 2017-09-27 A | 2017-11-14 A |  | 100% |  |  |  |  | Ken Heller | 20h | 20h |
| 25 | 1.11.2 | Receive all mechanical parts |  | 10d | 2017-09-27 A | 2018-01-09 A |  | 100% |  |  |  |  | Mike Parker | 80h | 80h |
| 26 | 1.11.3 | Load control backplane complete |  | 20d | 2017-11-10 A | 2018-03-02 |  | 75% | 5d | 108d |  | start no earlier than 2017-11-10 | Jose Rosal | 160h | 120h |
| 27 | 1.11.4 | Analog load control board complete |  | 35d | 2017-11-10 A | 2018-03-08 |  | 75% | 8.75d | 34.25d | 9.75d | start no earlier than 2017-11-10 | Jose Rosal | 280h | 210h |
| 28 | 1.11.5 | Complete high voltage converter PCB assembly |  | 40d | 2018-01-01 A | 2018-03-15 |  | 65% | 14d | 29d | 4.5d | start no earlier than 2018-01-01 | Ed Mellinger | 320h | 208h |
| 29 | 1.12 | A-201908-17_Stbd & Port_EZSV_Assem_Rev.A |  | 2d | 2017-11-03 A | 2018-01-10 A |  | 100% |  |  |  | start no earlier than 2017-09-27 | Jim Scholfield | 16h | 16h |
| 30 | 1.13 | A-200508-08_MotorAssem |  | 2d | 2017-09-27 A | 2017-11-13 A |  | 100% |  |  |  | start no earlier than 2017-09-27 | Jim Scholfield | 16h | 16h |
| 31 | 1.14 | A-200567-08_PropShaftAssem |  | 10d | 2018-01-08 A | 2018-03-02 |  | 50% | 5d | 58d |  | start no earlier than 2018-01-08 | Mike Parker | 80h | 40h |
| 32 | 1.15 | A-200503-08_ThrusterMotorAssy_V3 |  | 10d | 2018-01-08 A | 2018-02-28 | 30 | 75% | 2.5d | 40.5d | 16d | start no earlier than 2018-01-08 | Jim Scholfield | 80h | 60h |
| 33 | 1.16 | Receive & Fabricate Qty 4 A-Launch_Cart_Frame |  | 3.75d | 2017-10-26 A | 2017-12-14 A |  | 100% |  |  |  | start no earlier than 2017-09-27 | Jim Scholfield | 30h | 30h |
| 34 | 1.17 | Assemble internal chassis components for harness fit |  | 5d | 2018-01-16 A | 2018-01-22 A | 26 | 100% |  |  |  | start no earlier than 2017-12-08 | Jim Scholfield | 40h | 40h |
| 35 | 1.18 | Test fit first article wire harness's |  | 2d | 2018-01-23 A | 2018-02-26 | 34 | 95% | 0.1d | 112.9d |  | start no earlier than 2017-12-15 | Jose Rosal | 16h | 15.2h |
| 36 | 1.19 | Receive final wire harness's |  | 20d | 2018-01-25 A | 2018-02-21 A | 35 | 100% |  |  |  | start no earlier than 2017-12-19 | Jose Rosal | 160h | 160h |
| 37 | 1.20 | Final assembly of all internal pressure hull components |  | 20d | 2018-03-22 | 2018-04-19 | 33, 32, 25, 18, 17, 11, 10, 8, 5, 24, 29, 36, 27, 28, 22 |  |  | 24.5d | 0d | start no earlier than 2018-01-16 | Jim Scholfield | 160h |  |
| 38 | 1.21 | Paint aluminum pressure hulls |  | 30d | 2018-01-05 A | 2018-02-15 A |  | 100% |  |  |  | start no earlier than 2018-01-05 | Water Rat | 240h | 240h |
| 39 | 1.22 | All A-200467-17_PressHull_components complete | milestone | 0d | 2018-04-19 | 2018-04-19 | 37 |  |  | 24.5d |  |  |  |  |  |

| ID | WBS | Task | Type | Duration | Start | Finish | Predecessors | Complete | Remaining | Total slack | Free slack | Constraint | Resources | Work | Actual work |
| --- | --- | --- | --- | --- | --- | --- | --- | --- | --- | --- | --- | --- | --- | --- | --- |
| 40 | 2 | **A-200502-08_TailControlAssem_V7** |  | 171d | 2017-09-27 A | 2018-05-23 |  | 65% | 59.72d | 30.75d |  | start no earlier than 2017-09-27 |  | 2806.42h | 1974.02h |
| 41 | 2.1 | A-200618-08_Fin_Assem_V6, fab. & weld fin axles |  | 29d | 2017-09-27 A | 2018-03-05 |  | 80% | 5.8d | 107.2d |  | start no earlier than 2017-09-27 | Mike Parker | 232h | 185.6h |
| 42 | 2.2 | A-200618-08_Fin_Assem_V6, receive final molded fins |  | 20d | 2018-01-05 A | 2018-02-01 A | 41FF | 100% |  |  |  | start no earlier than 2018-01-05 | Mike Parker | 160h | 160h |
| 43 | 2.3 | A-200711-09_CS_LDA_Acuator wiring and assembly |  | 30d | 2017-11-10 A | 2018-03-01 |  | 87% | 4d | 54d | 0d | start no earlier than 2017-11-10 | Jose Rosal; Jim Scholfield | 480h | 416h |
| 44 | 2.4 | Test CS_LDA Acuator assembly |  | 5d | 2018-03-02 | 2018-03-08 | 43 |  |  | 54d |  |  | Ben | 40h |  |
| 45 | 2.5 | A-200731-09_ElvCrnk/A-200732-09_RuddrCrnk 1st article insp. | milestone | 0d | 2018-01-04 A | 2018-01-04 A |  | 100% |  |  |  | finish no earlier than 2018-01-04 | Mike Parker |  |  |
| 46 | 2.6 | A-200731-09_ElvCrnk/A-200732-09_RuddrCrnk fabrication |  | 10d | 2018-01-09 A | 2018-01-22 A | 45 | 100% |  |  |  | start no earlier than 2018-01-08 | Machine Shop | 80h | 80h |
| 47 | 2.7 | Weld WHOI A-200731-09_ElvCrnk/A-200732-09 |  | 2d | 2018-02-23 | 2018-02-26 |  |  |  | 62d |  | start no earlier than 2018-02-23 | Mike Parker [25%] | 4h |  |
| 48 | 2.8 | A-200751-09_TailShellAssem, fabricate shell unit #1 |  | 33d | 2018-01-08 A | 2018-02-21 A |  | 100% |  |  |  | finish no earlier than 2018-02-21 | Pleskunas Design LLC | 264h | 264h |
| 49 | 2.9 | A-200751-09_TailShellAssem, fabricate shell unit #2 |  | 33d | 2018-02-26 | 2018-04-11 |  |  |  | 30d |  | start no earlier than 2018-02-23 | Pleskunas Design LLC | 264h |  |
| 50 | 2.10 | A-200924-10_ExtBladderAssem |  | 10d | 2018-01-09 A | 2018-01-22 A |  | 100% |  |  |  | start no earlier than 2018-01-08 | Jim Scholfield; Mike Parker | 82h | 82h |
| 51 | 2.11 | A-201176-17_CompAssem_V2 |  | 5d | 2017-10-10 A | 2017-11-29 A |  | 100% |  |  |  | start no earlier than 2017-09-27 | Jim Scholfield | 40h | 40h |
| 52 | 2.12 | Oil fill and leak test CompAssem_V2 |  | 5d | 2017-11-30 A | 2018-03-01 | 51 | 25% | 3.75d | 59.25d |  |  | Jim Scholfield | 40h | 10h |
| 53 | 2.13 | A-201500-17_DW_HrdWrAssem Fabrication |  | 20d | 2018-02-26 | 2018-03-23 |  |  |  | 43d |  | start no earlier than 2018-02-23 | Jim Scholfield | 160h |  |
| 54 | 2.14 | Receive A-201916-17_TailFoamAssy_V6 |  | 30d | 2017-10-20 A | 2018-01-30 A |  | 100% |  |  |  |  |  |  |  |
| 55 | 2.15 | **A-201798-16_Antenna Rev.I** |  | 171d | 2017-09-27 A | 2018-05-23 |  | 60% | 67.75d | 18d |  |  |  | 960.42h | 736.42h |
| 56 | 2.15.1 | Design new antenna base |  | 1d | 2017-09-27 A | 2018-01-02 A |  | 100% |  |  |  |  | Brett Hobson | 8h | 8h |
| 57 | 2.15.2 | Deliver Antenna drawings with wire length to Jose |  | 1d | 2017-11-10 A | 2017-11-10 A |  | 100% |  |  |  | start no earlier than 2017-11-10 | Brett Hobson | 8h | 8h |
| 58 | 2.15.3 | Solder in coax to Antenna PCB |  | 3d | 2018-01-08 A | 2018-01-10 A | 57 | 100% |  |  |  | start no earlier than 2018-01-08 | Jose Rosal | 24h | 24h |
| 59 | 2.15.4 | Receive parts for antenna and MUX PCB's |  | 25d | 2017-11-10 A | 2017-12-14 A |  | 100% |  |  |  | start no earlier than 2017-11-10 | Jose Rosal | 200h | 200h |
| 60 | 2.15.5 | Complete test molding |  | 6d | 2017-12-19 A | 2018-01-10 A | 59, 58FF, 56 | 100% |  |  |  |  | Brett Hobson | 16.42h | 16.42h |
| 61 | 2.15.6 | Mold antennas |  | 20d | 2018-01-11 A | 2018-02-07 A | 60 | 100% |  |  |  | start no earlier than 2018-01-08 | Brett Hobson | 160h | 160h |
| 62 | 2.15.7 | Order and receive coax antenna wet cable |  | 10d | 2017-12-18 A | 2017-12-29 A |  | 100% |  |  |  | start no earlier than 2017-12-17 | Mark Chaffey | 80h | 80h |
| 63 | 2.15.8 | Over mold antenna coax with Poly U |  | 30d | 2018-01-01 A | 2018-02-09 A | 62 | 100% |  |  |  |  | Mark Chaffey | 240h | 240h |
| 64 | 2.15.9 | Terminate antenna wet cable with SMA conn |  | 20d | 2018-02-26 | 2018-03-23 | 63 |  |  | 20.75d | 0d | start no earlier than 2018-02-23 | Jose Rosal | 160h |  |
| 65 | 2.15.10 | Terminate antenna wet cable with DGO conn |  | 35d | 2018-03-26 | 2018-05-11 | 64 |  |  | 20.75d | 0d |  |  |  |  |
| 66 | 2.15.11 | Cast antenna base sealing connectors |  | 8d | 2018-05-14 | 2018-05-23 | 65, 61 |  |  | 20.75d | 15.5d |  | Jim Scholfield | 64h |  |
| 67 | 2.16 | A-200502-08_TailControlAssemComplete | milestone | 0d | 2018-04-11 | 2018-04-11 | 54, 53, 51, 50, 48, 46, 42, 31, 49, 44, 52, 47 |  |  | 10.75d | 5.5d | start no earlier than 2018-02-02 |  |  |  |

| ID | WBS | Task | Type | Duration | Start | Finish | Predecessors | Complete | Remaining | Total slack | Free slack | Constraint | Resources | Work | Actual work |
| --- | --- | --- | --- | --- | --- | --- | --- | --- | --- | --- | --- | --- | --- | --- | --- |
| 68 | 3 | **A-xxxxxx-xx_PayLoad-ShortNose (Kemp)** |  | 199d | 2017-09-27 A | 2018-07-02 |  |  | 199d | 0d |  |  |  | 2040h |  |
| 69 | 3.1 | Specify shortnose payload design |  | 2.5d | 2017-09-27 A | 2018-02-28 |  |  | 2.5d | 25.5d | 0d |  | Brett Hobson | 20h |  |
| 70 | 3.2 | Design housing for shortnose AHRS | milestone | 0d | 2017-09-27 A | 2017-10-10 A |  | 100% |  |  |  |  | Brett Hobson; Jon Erickson |  |  |
| 71 | 3.3 | Fabricate AHRS housing |  | 20d | 2018-02-28 | 2018-03-28 | 70, 69 |  |  | 35.5d | 10d | start no earlier than 2018-01-08 | Machine Shop | 160h |  |
| 72 | 3.4 | Fabricate or locate all shortnose parts |  | 30d | 2018-02-28 | 2018-04-11 | 69 |  |  | 25.5d | 0d | start no earlier than 2018-01-08 | Brett Hobson; Jon Erickson | 480h |  |
| 73 | 3.5 | Assemble shortnose payload |  | 5d | 2018-04-11 | 2018-04-18 | 72, 71 |  |  | 25.5d | 0d | start no earlier than 2018-01-08 | Jim Scholfield | 40h |  |
| 74 | 3.6 | A-xxxxxx-xx_PayLoad-ShortNoseComplete | milestone | 0d | 2018-04-18 | 2018-04-18 | 73 |  |  | 25.5d |  | start no earlier than 2018-01-08 |  |  |  |
| 75 | 3.7 | **AUV #4 (Kemp) Final Integration and test** |  | 92d | 2018-02-23 | 2018-07-02 |  |  |  | 0d |  | start no earlier than 2018-02-13 |  | 1340h |  |
| 76 | 3.7.1 | Complete first two deck boxes |  | 10d | 2018-02-23 | 2018-03-08 |  |  |  | 54d |  | start no earlier than 2018-02-23 | Paul Coenen [25%] | 20h |  |
| 77 | 3.7.2 | AUV #4 (Kemp) Final assembly of all components in chassis |  | 25d | 2018-03-15 | 2018-04-19 | 74FF, 67FF, 39FF |  |  | 2.5d | 0d | start no earlier than 2018-03-13 | Jim Scholfield | 200h |  |
| 78 | 3.7.3 | AUV #4 (Kemp) Lab systems integration and test |  | 40d | 2018-04-19 | 2018-06-14 | 77, 76, 66FF |  |  | 2.5d | 0d | start no earlier than 2018-03-13 | Brian Kieft; Mark Chaffey; Brett Hobson | 960h |  |
| 79 | 3.7.4 | AUV #4 (Kemp) Sea Trials |  | 10d | 2018-06-14 | 2018-06-28 | 78, 38 |  |  | 2.5d |  | start no earlier than 2018-05-08 | Brett Hobson; Brian Kieft | 160h |  |
| 80 | 3.7.5 | AUV #4 (Kemp) Complete | milestone | 0d | 2018-07-02 | 2018-07-02 | 79 |  |  | 0d |  | must finish on 2018-07-02 |  |  |  |
| 81 | 4 | **AUV 5,6,7 science payload Systems** |  | 201.75d | 2017-09-27 A | 2018-07-05 |  | 2% | 197.23d | 0d |  |  |  | 1420h | 30h |
| 82 | 4.1 | Specify AUV 5,6,7 science payload design |  | 7.5d | 2017-09-27 A | 2018-03-01 |  | 50% | 3.75d | 0d |  |  | Brett Hobson | 60h | 30h |
| 83 | 4.2 | Complete design drawings for science payload |  | 20d | 2018-03-01 | 2018-03-29 | 82 |  |  | 0d |  | start no earlier than 2018-01-08 | Brett Hobson; Jon Erickson | 320h |  |
| 84 | 4.3 | Design review science payload design | milestone | 0d | 2018-03-29 | 2018-03-29 | 83 |  |  | 0d |  | start no earlier than 2018-01-08 | Brett Hobson |  |  |
| 85 | 4.4 | Fabricate and paint nose shell |  | 40d | 2018-03-29 | 2018-05-24 | 38FF, 84 |  |  | 49.25d |  | start no earlier than 2018-01-08 | Water Rat | 320h |  |
| 86 | 4.5 | Fabricate all nose cone hardware |  | 30d | 2018-03-29 | 2018-05-10 | 84 |  |  | 29.25d | 10d | start no earlier than 2018-01-08 |  |  |  |
| 87 | 4.6 | Order and receive nose cone wet cabling |  | 40d | 2018-03-29 | 2018-05-24 | 84 |  |  | 0d |  | start no earlier than 2018-01-08 | Mark Chaffey | 320h |  |
| 88 | 4.7 | Assemble science payload AUV 5, 6 & 7 |  | 20d | 2018-05-24 | 2018-06-21 | 87, 86 |  |  | 0d |  | start no earlier than 2018-02-07 | Jim Scholfield; Mark Chaffey | 320h |  |
| 89 | 4.8 | Final assembly LRAUV #5, 6 & 7 |  | 10d | 2018-06-21 | 2018-07-05 | 39, 67, 88 |  |  | 0d |  | start no earlier than 2018-03-07 | Jim Scholfield | 80h |  |
