# LRAUVBuildScheduleRev.A_Backup

Schedule from MS Project, 2017-09-27 to 2018-08-15, A marks actual dates.
Hewlett-Packard Company

## Calendars

- Standard: Mon-Fri 08:00-12:00, 13:00-17:00; Sat-Sun off.

## Resources

| Resource |
| --- |
| Water Rat |
| Jim Scholfield |
| Mark Chaffey |
| Jose Rosal |
| Ken Heller |
| Denis Klimov |
| Ed Mellinger |
| Brett Hobson |
| Brian Kieft |
| Mike Parker |
| Machine Shop |
| Jon Erickson |
| Craig Okuda |

## Schedule

| ID | WBS | Task | Type | Duration | Start | Finish | Predecessors | Complete | Remaining | Total slack | Free slack | Constraint | Resources | Work | Actual work |
| --- | --- | --- | --- | --- | --- | --- | --- | --- | --- | --- | --- | --- | --- | --- | --- |
| 1 | 1 | **A-200467-17_PressHull_BUILD_5** |  | 134d | 2017-09-27 A | 2018-04-02 |  | 38% | 82.61d | 97d |  |  |  | 2658h | 972h |
| 2 | 1.1 | Receive P-200626_AlumPressHull_EndDome_FWD_Rev.G |  | 1d | 2017-09-27 A | 2017-09-27 A |  | 100% |  |  |  |  |  |  |  |
| 3 | 1.2 | Receive fwd bulkhead connectors |  | 10d | 2017-09-27 A | 2017-10-10 A |  | 100% |  |  |  |  |  |  |  |
| 4 | 1.3 | FWD dome wiring |  | 5d | 2017-10-11 A | 2018-01-15 | 3, 2 |  | 5d | 124.5d | 0d |  | Jose Rosal | 40h |  |
| 5 | 1.4 | Assemble A-200579-14_InternalChassis_V3 |  | 10d | 2017-11-15 A | 2018-01-25 | 4 | 25% | 7.5d | 124.5d | 27.5d |  | Jim Scholfield | 80h | 20h |
| 6 | 1.5 | Receive P-200466-08_EndDome_AFT_Rev.C |  | 1d | 2017-09-27 A | 2017-09-27 A |  | 100% |  |  |  | start no earlier than 2017-09-27 |  |  |  |
| 7 | 1.6 | Receive aft bulkhead connectors |  | 10d | 2017-09-27 A | 2017-10-10 A |  | 100% |  |  |  |  |  |  |  |
| 8 | 1.7 | AFT dome wiring |  | 5d | 2017-10-11 A | 2018-01-15 | 7, 6 |  | 5d | 132d | 35d |  | Jose Rosal | 40h |  |
| 9 | 1.8 | **A-201330-12_VB-Sys_V2** |  | 82d | 2017-09-27 A | 2018-01-18 |  | 65% | 28.5d | 129d |  |  |  | 40h | 20h |
| 10 | 1.8.1 | A-200620-08_VB-Resrvoir |  | 2.5d | 2017-09-27 A | 2018-01-10 |  | 50% | 1.25d | 135.75d | 38.75d | start no earlier than 2017-09-27 | Jim Scholfield | 20h | 10h |
| 11 | 1.8.2 | P-201775-16 Valve Panel Mount Bracket fabrication |  | 16d | 2017-10-31 A | 2018-01-18 |  | 70% | 4.8d | 129d | 0d | finish no earlier than 2017-11-21 |  |  |  |
| 12 | 1.8.3 | A-200991-11_ValveAssem final assembly |  | 2.5d | 2017-09-27 A | 2018-01-18 | 11FF | 50% | 1.25d | 129d | 32d | start no earlier than 2017-09-27 | Jim Scholfield | 20h | 10h |
| 13 | 1.9 | **A-201541-13_SecBattAssem_V3.3** |  | 95d | 2017-09-27 A | 2018-02-06 |  | 43% | 53.7d | 116d |  | start no earlier than 2017-09-27 |  | 520h | 320h |
| 14 | 1.9.1 | Assemble half-pak battery modules |  | 5d | 2017-09-27 A | 2017-11-16 A |  | 100% |  |  |  | start no earlier than 2017-09-27 | Denis Klimov; Ken Heller | 80h | 80h |
| 15 | 1.9.2 | Test half-pak battery modules |  | 20d | 2017-11-17 A | 2018-01-15 | 14 | 75% | 5d | 116d | 0d | start no earlier than 2017-11-17 | Denis Klimov; Ken Heller | 320h | 240h |
| 16 | 1.9.3 | Degauss half-pak battery modules |  | 6d | 2018-01-16 | 2018-01-23 | 15 |  |  | 116d | 0d | start no earlier than 2018-01-08 |  |  |  |
| 17 | 1.9.4 | Assemble complete battery module |  | 5d | 2018-01-24 | 2018-01-30 | 16 |  |  | 116d | 0d | start no earlier than 2018-01-08 | Ken Heller | 40h |  |
| 18 | 1.9.5 | A-201907-17_FlagAssem_V2 |  | 5d | 2018-01-31 | 2018-02-06 | 17 |  |  | 116d | 19d | start no earlier than 2018-01-08 | Jim Scholfield | 40h |  |
| 19 | 1.9.6 | A-201567-14_Complete Drive Assembly_V4 |  | 5d | 2018-01-31 | 2018-02-06 | 17 |  |  | 116d | 19d | start no earlier than 2018-01-08 | Jim Scholfield | 40h |  |
| 20 | 1.10 | **A-201882-17_RF chassis_V2** |  | 47d | 2017-11-10 A | 2018-01-15 |  | 88% | 5.88d | 132d |  | start no earlier than 2017-11-10 |  | 320h | 280h |
| 21 | 1.10.1 | Replace RF MUX PCB component |  | 30d | 2017-11-10 A | 2017-12-21 A |  | 100% |  |  |  | start no earlier than 2017-11-10 | Jose Rosal | 240h | 240h |
| 22 | 1.10.2 | 3 way mux assembly complete |  | 5d | 2017-12-22 A | 2017-12-28 A | 21 | 100% |  |  |  | start no earlier than 2017-12-22 | Jose Rosal | 40h | 40h |
| 23 | 1.10.3 | Test 3 way mux assembly |  | 5d | 2018-01-09 | 2018-01-15 | 22 |  |  | 132d | 35d | start no earlier than 2018-01-08 | Craig Okuda | 40h |  |
| 24 | 1.11 | **A-201904-17_LoadContAssem_V2** |  | 114d | 2017-09-27 A | 2018-03-05 |  | 33% | 76.09d | 97d |  |  |  | 860h | 286h |
| 25 | 1.11.1 | Receive and configure load control boards |  | 2.5d | 2017-09-27 A | 2017-11-14 A |  | 100% |  |  |  |  | Ken Heller | 20h | 20h |
| 26 | 1.11.2 | Receive all mechanical parts |  | 10d | 2017-09-27 A | 2018-01-09 |  | 95% | 0.5d | 136.5d | 39.5d |  | Mike Parker | 80h | 76h |
| 27 | 1.11.3 | Load control backplane complete |  | 20d | 2017-11-10 A | 2018-01-15 |  | 75% | 5d | 105d | 0d | start no earlier than 2017-11-10 | Jose Rosal | 160h | 120h |
| 28 | 1.11.4 | Analog load control board complete |  | 35d | 2017-11-10 A | 2018-02-14 |  | 25% | 26.25d | 110.75d | 13.75d | start no earlier than 2017-11-10 | Jose Rosal | 280h | 70h |
| 29 | 1.11.5 | Complete high voltage converter PCB assembly |  | 40d | 2018-01-09 | 2018-03-05 |  |  |  | 97d | 0d | start no earlier than 2018-01-08 | Ed Mellinger | 320h |  |
| 30 | 1.12 | A-201908-17_Stbd & Port_EZSV_Assem_Rev.A |  | 2d | 2017-11-03 A | 2018-01-10 |  |  | 2d | 135d | 38d | start no earlier than 2017-09-27 | Jim Scholfield | 16h |  |
| 31 | 1.13 | A-200508-08_MotorAssem |  | 2d | 2017-09-27 A | 2017-11-13 A |  | 100% |  |  |  | start no earlier than 2017-09-27 | Jim Scholfield | 16h | 16h |
| 32 | 1.14 | A-200503-08_ThrusterMotorAssy_V3 |  | 10d | 2018-01-08 | 2018-01-19 | 31 |  |  | 128d | 31d | start no earlier than 2018-01-08 | Jim Scholfield | 80h |  |
| 33 | 1.15 | Receive & Fabricate Qty 4 A-Launch_Cart_Frame |  | 3.75d | 2017-10-26 A | 2017-12-14 A |  | 100% |  |  |  | start no earlier than 2017-09-27 | Jim Scholfield | 30h | 30h |
| 34 | 1.16 | Assemble internal chassis components for harness fit |  | 5d | 2018-01-16 | 2018-01-22 | 27 |  |  | 105d | 0d | start no earlier than 2017-12-08 | Jim Scholfield | 40h |  |
| 35 | 1.17 | Test fit first article wire harness's |  | 2d | 2018-01-23 | 2018-01-24 | 34 |  |  | 105d | 0d | start no earlier than 2017-12-15 | Jose Rosal | 16h |  |
| 36 | 1.18 | Receive final wire harness's |  | 20d | 2018-01-25 | 2018-02-21 | 35 |  |  | 105d | 8d | start no earlier than 2017-12-19 | Jose Rosal | 160h |  |
| 37 | 1.19 | Final assembly of all internal pressure hull components |  | 20d | 2018-03-06 | 2018-04-02 | 33, 32, 26, 19, 18, 12, 10, 8, 5, 25, 30, 36, 28, 29, 23 |  |  | 97d |  | start no earlier than 2018-01-16 | Jim Scholfield | 160h |  |
| 38 | 1.20 | Paint aluminum pressure hulls |  | 30d | 2018-01-09 | 2018-02-19 |  |  |  | 117d | 33.75d | start no earlier than 2018-01-08 | Water Rat | 240h |  |
| 39 | 1.21 | All A-200467-17_PressHull_components complete | milestone | 0d | 2018-02-13 A | 2018-02-13 A | 37 | 100% |  |  |  |  |  |  |  |

| ID | WBS | Task | Type | Duration | Start | Finish | Predecessors | Complete | Remaining | Total slack | Free slack | Constraint | Resources | Work | Actual work |
| --- | --- | --- | --- | --- | --- | --- | --- | --- | --- | --- | --- | --- | --- | --- | --- |
| 40 | 2 | **A-200502-08_TailControlAssem_V7** |  | 161d | 2017-09-27 A | 2018-05-09 |  | 27% | 117.17d | 0d |  | start no earlier than 2017-09-27 |  | 2916h | 870h |
| 41 | 2.1 | A-200618-08_Fin_Assem_V6, receive fin axles |  | 29d | 2017-09-27 A | 2018-01-18 |  | 75% | 7.25d | 79.75d | 12.75d | start no earlier than 2017-09-27 | Mike Parker | 232h | 174h |
| 42 | 2.2 | A-200618-08_Fin_Assem_V6, receive final molded fins |  | 20d | 2018-01-09 | 2018-02-05 | 41FF |  |  | 67d |  | start no earlier than 2018-01-08 | Mike Parker | 160h |  |
| 43 | 2.3 | A-200711-09_CS_LDA_Acuator wiring and assembly |  | 30d | 2017-11-10 A | 2018-01-29 |  | 50% | 15d | 72d |  | start no earlier than 2017-11-10 | Jose Rosal; Jim Scholfield | 480h | 240h |
| 44 | 2.4 | A-200731-09_ElvCrnk/A-200732-09_RuddrCrnk 1st article insp. | milestone | 0d | 2018-01-08 | 2018-01-08 |  |  |  | 77d | 0d | start no earlier than 2018-01-08 | Mike Parker |  |  |
| 45 | 2.5 | A-200731-09_ElvCrnk/A-200732-09_RuddrCrnk fabrication |  | 10d | 2018-01-09 | 2018-01-22 | 44 |  |  | 77d |  | start no earlier than 2018-01-08 | Machine Shop | 80h |  |
| 46 | 2.6 | Bond A-200751-09_HATCH_TailShellAssem, fabricate hatch |  | 1d | 2018-01-09 | 2018-01-09 |  |  |  | 86d | 59d | start no earlier than 2018-01-08 | Water Rat | 8h |  |
| 47 | 2.7 | A-200751-09_TailShellAssem, fabricate shell |  | 60d | 2018-01-09 | 2018-04-02 | 46FF |  |  | 27d |  | start no earlier than 2018-01-08 | Water Rat | 480h |  |
| 48 | 2.8 | A-200924-10_ExtBladderAssem |  | 10d | 2018-01-09 | 2018-01-22 |  |  |  | 77d |  | start no earlier than 2018-01-08 | Jim Scholfield | 80h |  |
| 49 | 2.9 | A-201176-17_CompAssem_V2 |  | 5d | 2017-10-10 A | 2017-11-29 A |  | 100% |  |  |  | start no earlier than 2017-09-27 | Jim Scholfield | 40h | 40h |
| 50 | 2.10 | A-201500-17_DW_HrdWrAssem Fabrication |  | 20d | 2018-01-09 | 2018-02-05 |  |  |  | 67d |  | start no earlier than 2018-01-08 | Jim Scholfield | 160h |  |
| 51 | 2.11 | Receive A-201916-17_TailFoamAssy_V6 |  | 30d | 2017-10-20 A | 2018-01-29 |  | 50% | 15d | 0d |  | must start on 2017-10-20 |  |  |  |
| 52 | 2.12 | **A-201798-16_Antenna Rev.I** |  | 161d | 2017-09-27 A | 2018-05-09 |  | 28% | 115.62d | 0d |  |  |  | 1196h | 416h |
| 53 | 2.12.1 | Design new antenna base |  | 7.5d | 2017-09-27 A | 2018-01-18 |  |  | 7.5d | 59.5d | 0d |  | Brett Hobson | 60h |  |
| 54 | 2.12.2 | Fabricate new antenna base |  | 20d | 2018-01-18 | 2018-02-15 | 53 |  |  | 59.5d |  | start no earlier than 2018-01-08 | Brett Hobson | 160h |  |
| 55 | 2.12.3 | Deliver Antenna drawings with wire length to Jose |  | 1d | 2017-11-10 A | 2017-11-10 A |  | 100% |  |  |  | start no earlier than 2017-11-10 | Brett Hobson | 8h | 8h |
| 56 | 2.12.4 | Solder in coax to Antenna PCB |  | 3d | 2018-01-09 | 2018-01-11 | 55 |  |  | 84d |  | start no earlier than 2018-01-08 | Jose Rosal | 24h |  |
| 57 | 2.12.5 | Receive parts for antenna and MUX PCB's |  | 25d | 2017-11-10 A | 2017-12-14 A |  | 100% |  |  |  | start no earlier than 2017-11-10 | Jose Rosal | 200h | 200h |
| 58 | 2.12.6 | Complete test molding |  | 10d | 2017-12-19 A | 2018-01-02 A | 54, 57, 56 | 100% |  |  |  | start no earlier than 2017-12-19 | Brett Hobson | 80h | 80h |
| 59 | 2.12.7 | Mold antennas |  | 15d | 2018-01-09 | 2018-01-29 | 58 |  |  | 64d |  | start no earlier than 2018-01-08 | Brett Hobson | 120h |  |
| 60 | 2.12.8 | Order and receive coax antenna wet cable |  | 10d | 2017-12-18 A | 2017-12-29 A |  | 100% |  |  |  | start no earlier than 2017-12-17 | Mark Chaffey | 80h | 80h |
| 61 | 2.12.9 | Over mold antenna coax with Poly U |  | 30d | 2018-01-01 A | 2018-02-09 | 60 | 20% | 24d | 0d |  |  | Mark Chaffey | 240h | 48h |
| 62 | 2.12.10 | Terminate antenna wet cable with SMA conn |  | 20d | 2018-02-12 | 2018-03-09 | 61 |  |  | 0d |  |  | Jose Rosal | 160h |  |
| 63 | 2.12.11 | Terminate antenna wet cable with DGO conn |  | 35d | 2018-03-12 | 2018-04-27 | 62 |  |  | 0d |  |  |  |  |  |
| 64 | 2.12.12 | Cast antenna base sealing connectors |  | 8d | 2018-04-30 | 2018-05-09 | 63, 59 |  |  | 0d |  |  | Jim Scholfield | 64h |  |
| 65 | 2.13 | A-200502-08_TailControlAssemComplete | milestone | 0d | 2018-05-09 | 2018-05-09 | 51, 52, 50, 49, 48, 47, 45, 43, 42, 64 |  |  | 0d |  | start no earlier than 2018-02-02 |  |  |  |

| ID | WBS | Task | Type | Duration | Start | Finish | Predecessors | Complete | Remaining | Total slack | Free slack | Constraint | Resources | Work | Actual work |
| --- | --- | --- | --- | --- | --- | --- | --- | --- | --- | --- | --- | --- | --- | --- | --- |
| 66 | 3 | **A-xxxxxx-xx_PayLoad-ShortNose (Kemp)** |  | 231d | 2017-09-27 A | 2018-08-15 |  |  | 231d | 0d |  |  |  | 1980h |  |
| 67 | 3.1 | Specify shortnose payload design |  | 2.5d | 2017-09-27 A | 2018-01-11 |  |  | 2.5d | 49.5d | 0d |  | Brett Hobson | 20h |  |
| 68 | 3.2 | Design housing for shortnose AHRS | milestone | 0d | 2017-09-27 A | 2017-10-10 A |  | 100% |  |  |  |  | Brett Hobson; Jon Erickson |  |  |
| 69 | 3.3 | Fabricate AHRS housing |  | 20d | 2018-01-11 | 2018-02-08 | 68, 67 |  |  | 59.5d | 10d | start no earlier than 2018-01-08 | Machine Shop | 160h |  |
| 70 | 3.4 | Fabricate or locate all shortnose parts |  | 30d | 2018-01-11 | 2018-02-22 | 67 |  |  | 49.5d | 0d | start no earlier than 2018-01-08 | Brett Hobson; Jon Erickson | 480h |  |
| 71 | 3.5 | Assemble shortnose payload |  | 5d | 2018-02-22 | 2018-03-01 | 70, 69 |  |  | 49.5d | 0d | start no earlier than 2018-01-08 | Jim Scholfield | 40h |  |
| 72 | 3.6 | A-xxxxxx-xx_PayLoad-ShortNoseComplete | milestone | 0d | 2018-03-01 | 2018-03-01 | 71 |  |  | 49.5d |  | start no earlier than 2018-01-08 |  |  |  |
| 73 | 3.7 | **AUV #4 (Kemp) Final Integration and test** |  | 70d | 2018-05-10 | 2018-08-15 |  |  |  | 0d |  | start no earlier than 2018-02-13 |  | 1280h |  |
| 74 | 3.7.1 | AUV #4 (Kemp) Final assembly of all components |  | 20d | 2018-05-10 | 2018-06-06 | 72, 65, 39 |  |  | 0d |  | start no earlier than 2018-02-13 | Jim Scholfield | 160h |  |
| 75 | 3.7.2 | AUV #4 (Kemp) Lab systems integration and test |  | 40d | 2018-06-07 | 2018-08-01 | 74 |  |  | 0d |  | start no earlier than 2018-03-13 | Brian Kieft; Mark Chaffey; Brett Hobson | 960h |  |
| 76 | 3.7.3 | AUV #4 (Kemp) Sea Trials |  | 10d | 2018-08-02 | 2018-08-15 | 75, 38 |  |  | 0d |  | start no earlier than 2018-05-08 | Brett Hobson; Brian Kieft | 160h |  |
| 77 | 3.7.4 | AUV #4 (Kemp) Complete | milestone | 0d | 2018-08-15 | 2018-08-15 | 76 |  |  | 0d |  | start no earlier than 2018-05-22 |  |  |  |
| 78 | 4 | **AUV 5,6,7 science payload Systems** |  | 171d | 2017-09-27 A | 2018-05-23 |  | 2% | 167.17d | 60d |  |  |  | 1420h | 30h |
| 79 | 4.1 | Specify AUV 5,6,7 science payload design |  | 7.5d | 2017-09-27 A | 2018-01-12 |  | 50% | 3.75d | 63.25d | 0d |  | Brett Hobson | 60h | 30h |
| 80 | 4.2 | Complete design drawings for science payload |  | 20d | 2018-01-12 | 2018-02-09 | 79 |  |  | 63.25d | 0d | start no earlier than 2018-01-08 | Brett Hobson; Jon Erickson | 320h |  |
| 81 | 4.3 | Design review science payload design | milestone | 0d | 2018-02-09 | 2018-02-09 | 80 |  |  | 63.25d | 0d | start no earlier than 2018-01-08 | Brett Hobson |  |  |
| 82 | 4.4 | Fabricate and paint nose shell |  | 40d | 2018-02-09 | 2018-04-06 | 38FF, 81 |  |  | 93.25d |  | start no earlier than 2018-01-08 | Water Rat | 320h |  |
| 83 | 4.5 | Fabricate all nose cone hardware |  | 30d | 2018-02-09 | 2018-03-23 | 81 |  |  | 73.25d | 10d | start no earlier than 2018-01-08 |  |  |  |
| 84 | 4.6 | Order and receive nose cone wet cabling |  | 40d | 2018-02-09 | 2018-04-06 | 81 |  |  | 63.25d | 0d | start no earlier than 2018-01-08 | Mark Chaffey | 320h |  |
| 85 | 4.7 | Assemble science payload AUV 5, 6 & 7 |  | 20d | 2018-04-06 | 2018-05-04 | 84, 83 |  |  | 63.25d | 3.25d | start no earlier than 2018-02-07 | Jim Scholfield; Mark Chaffey | 320h |  |
| 86 | 4.8 | Final assembly LRAUV #5, 6 & 7 |  | 10d | 2018-05-10 | 2018-05-23 | 39, 65, 85 |  |  | 60d |  | start no earlier than 2018-03-07 | Jim Scholfield | 80h |  |
